# Inicio de la práctica 2

How a schedule from MS Project changed from version to version. A marks actual dates.

## Version 1 (saved 2009-03-03, file InicioPractica2.mpp)

| ID | WBS | Task | Duration | Start | Finish | Predecessors | Total float |
| --- | --- | --- | --- | --- | --- | --- | --- |
| 1 | 1 | **Topografía** | 101.5d | 2008-10-01 | 2009-02-25 |  | 0d |
| 2 |  | Implantación topográfica | 3d | 2008-10-01 | 2008-10-03 |  | 0d |
| 3 |  | Control topográfico antes de colocación de vigas | 0.5d | 2009-02-12 | 2009-02-12 | 34 | 1.5d |
| 4 |  | Control topográfico después de colocación de vigas | 0.5d | 2009-02-25 | 2009-02-25 | 37 | 0d |
| 5 | 2 | **Instalación de la obra** | 15d | 2008-10-06 | 2008-10-24 |  | 0d |
| 6 |  | Colocación planta de hormigonado | 15d | 2008-10-06 | 2008-10-24 | 2 | 0d |
| 7 |  | Instalación de la obra | 5d | 2008-10-06 | 2008-10-10 | 2 | 5d |
| 8 | 3 | **Prefabricación pilotes. Ferralla y encofrado** | 15d | 2008-10-13 | 2008-10-31 |  | 5d |
| 9 |  | Ferralla y encofrado lote 1 | 5d | 2008-10-13 | 2008-10-17 | 7 | 5d |
| 10 |  | Ferralla y encofrado lote 2 | 5d | 2008-10-20 | 2008-10-24 | 9 | 21d |
| 11 |  | Ferralla y encofrado lote 3 | 5d | 2008-10-27 | 2008-10-31 | 10 | 37d |
| 12 | 4 | **Prefebricación pilotes. Hormigonado** | 6d | 2008-10-27 | 2008-11-03 |  | 0d |
| 13 |  | Hormigonado lote 1 | 1d | 2008-10-27 | 2008-10-27 | 6, 9 | 0d |
| 14 |  | Hormigonado lote 2 | 1d | 2008-10-27 | 2008-10-27 | 10 | 21d |
| 15 |  | Hormigonado lote 3 | 1d | 2008-11-03 | 2008-11-03 | 11 | 37d |
| 16 | 5 | **Hincado de pilotes** | 32d | 2008-11-12 | 2008-12-29 |  | 0d |
| 17 |  | Hincado de pilotes de pilar A | 6d | 2008-11-12 | 2008-11-19 | 21, 13FS+15ed | 0d |
| 18 |  | Hincado de pilotes de pilar B | 6d | 2008-12-01 | 2008-12-09 | 22, 14FS+15ed | 7d |
| 19 |  | Hincado de pilotes de pilar C | 6d | 2008-12-19 | 2008-12-29 | 23, 15FS+15ed | 14d |
| 20 | 6 | **Diques provisionales** | 86d | 2008-10-13 | 2009-02-13 |  | 0d |
| 21 |  | Instalación de diques provisionales pilar A | 7d | 2008-10-13 | 2008-10-21 | 7 | 15d |
| 22 |  | Instalación de diques provisionales pilar B | 7d | 2008-11-20 | 2008-11-28 | 17 | 7d |
| 23 |  | Instalación de diques provisionales pilar C | 7d | 2008-12-10 | 2008-12-18 | 18, 26 | 14d |
| 24 |  | Recuperación de planchas | 2d | 2009-02-12 | 2009-02-13 | 34 | 0d |
| 25 | 7 | **Pasarela** | 93d | 2008-10-13 | 2009-02-24 |  | 12.5d |
| 26 |  | Instalación pasarelas | 5d | 2008-10-13 | 2008-10-17 | 7 | 50d |
| 27 |  | Desmontaje pasarelas | 7d | 2009-02-16 | 2009-02-24 | 24 | 12.5d |
| 28 | 8 | **Hormigonado de pilares** | 56d | 2008-11-20 | 2009-02-11 |  | 0d |
| 29 |  | Confección traviesas pilar A | 5d | 2008-11-20 | 2008-11-26 | 17 | 0d |
| 30 |  | Hormigonado pilar A | 15d | 2008-11-27 | 2008-12-18 | 29 | 0d |
| 31 |  | Confección traviesas pilar B | 5d | 2008-12-19 | 2008-12-26 | 18, 30 | 0d |
| 32 |  | Hormigonado pilar B | 15d | 2008-12-29 | 2009-01-20 | 31 | 0d |
| 33 |  | Confección traviesas pilar C | 5d | 2009-01-21 | 2009-01-27 | 19, 32 | 0d |
| 34 |  | Hormigonado pilar C | 11d | 2009-01-28 | 2009-02-11 | 33 | 0d |
| 35 | 9 | **Tablero** | 14.5d | 2009-02-16 | 2009-03-06 |  | 0d |
| 36 |  | Colocación vigas prefabricadas | 2d | 2009-02-16 | 2009-02-17 | 3, 24 | 0d |
| 37 |  | Encofrado tablero | 5d | 2009-02-18 | 2009-02-24 | 36 | 0d |
| 38 |  | Ferralla tablero | 5d | 2009-02-25 | 2009-03-04 | 4, 37 | 0d |
| 39 |  | Hormigonado tablero | 2d | 2009-03-04 | 2009-03-06 | 38 | 0d |
| 40 | 10 | **Pretil** | 113.5d | 2008-10-01 | 2009-03-13 |  | 0d |
| 41 |  | Pedido pretil | 0d | 2008-10-01 | 2008-10-01 |  | 88.5d |
| 42 |  | Colocación pretil | 5d | 2009-03-06 | 2009-03-13 | 39, 41FS+20d | 0d |

## Version 2 (data date 2008-12-01, saved 2009-03-13, file 2009-3-5-control1diciembre08.mpp)

Last finish 2009-03-13 → 2009-03-16 (+3d). Complete tasks 0 → 13.

Changed:

| ID | Task | Start | Finish | Duration | Complete | Total float | Other |
| --- | --- | --- | --- | --- | --- | --- | --- |
| 1 | **Topografía** | 2008-10-01 A | 2009-02-25 → 2009-03-02 (+5d) | 101.5d → 105d | 0% → 75% |  | baseline start none → 2008-10-01; baseline finish none → 2009-03-04 |
| 2 | Implantación topográfica | 2008-10-01 A | 2008-10-03 A |  | 0% → 100% | 0d → none | resources none → Topógrafo; Porta mira; Peones [200%]; baseline start none → 2008-10-01; baseline finish none → 2008-10-03 |
| 3 | Control topográfico antes de colocación de vigas | 2009-02-12 → 2009-02-20 (+8d) | 2009-02-12 → 2009-02-20 (+8d) |  |  |  | resources none → Topógrafo; Porta mira; baseline start none → 2009-02-24; baseline finish none → 2009-02-24 |
| 4 | Control topográfico después de colocación de vigas | 2009-02-25 → 2009-03-02 (+5d) | 2009-02-25 → 2009-03-02 (+5d) |  |  |  | resources none → Topógrafo; Porta mira; baseline start none → 2009-03-04; baseline finish none → 2009-03-04 |
| 5 | **Instalación de la obra** | 2008-10-06 A | 2008-10-24 → 2008-10-31 A (+7d) | 15d → 20d | 0% → 100% | 0d → none | baseline start none → 2008-10-06; baseline finish none → 2008-10-31 |
| 6 | Colocación planta de hormigonado | 2008-10-06 → 2008-10-13 A (+7d) | 2008-10-24 → 2008-10-31 A (+7d) |  | 0% → 100% | 0d → none | resources none → Peones [400%]; Grúa [10%]; Hormigonera; baseline start none → 2008-10-13; baseline finish none → 2008-10-31 |
| 7 | Instalación de la obra | 2008-10-06 A | 2008-10-10 A |  | 0% → 100% | 5d → none | resources none → Peones [300%]; Bulldozer con conductor; baseline start none → 2008-10-06; baseline finish none → 2008-10-10 |
| 8 | **Prefabricación pilotes. Ferralla y encofrado** | 2008-10-13 A | 2008-10-31 → 2008-11-05 A (+5d) | 15d → 18d | 0% → 100% | 5d → none | baseline start none → 2008-10-13; baseline finish none → 2008-10-31 |
| 9 | Ferralla y encofrado lote 1 | 2008-10-13 A | 2008-10-17 → 2008-10-16 A (-1d) | 5d → 4d | 0% → 100% | 5d → none | resources none → Peones; Albañiles [200%]; baseline start none → 2008-10-13; baseline finish none → 2008-10-17 |
| 10 | Ferralla y encofrado lote 2 | 2008-10-20 A | 2008-10-24 → 2008-10-27 A (+3d) | 5d → 6d | 0% → 100% | 21d → none | resources none → Peones; Albañiles [200%]; baseline start none → 2008-10-20; baseline finish none → 2008-10-24 |
| 11 | Ferralla y encofrado lote 3 | 2008-10-27 → 2008-10-29 A (+2d) | 2008-10-31 → 2008-11-05 A (+5d) | 5d → 6d | 0% → 100% | 37d → none | resources none → Peones; Albañiles [200%]; baseline start none → 2008-10-27; baseline finish none → 2008-10-31 |
| 12 | **Prefebricación pilotes. Hormigonado** | 2008-10-27 → 2008-11-03 A (+7d) | 2008-11-03 → 2008-11-18 A (+15d) | 6d → 12d | 0% → 100% | 0d → none | baseline start none → 2008-11-03; baseline finish none → 2008-11-14 |
| 13 | Hormigonado lote 1 | 2008-10-27 → 2008-11-03 A (+7d) | 2008-10-27 → 2008-11-03 A (+7d) |  | 0% → 100% | 0d → none | resources none → Peones [400%]; Albañiles; Hormigonera; baseline start none → 2008-11-03; baseline finish none → 2008-11-03 |
| 14 | Hormigonado lote 2 | 2008-10-27 → 2008-11-17 A (+21d) | 2008-10-27 → 2008-11-17 A (+21d) |  | 0% → 100% | 21d → none | resources none → Peones [400%]; Albañiles; Hormigonera; baseline start none → 2008-11-13; baseline finish none → 2008-11-13 |
| 15 | Hormigonado lote 3 | 2008-11-03 → 2008-11-18 A (+15d) | 2008-11-03 → 2008-11-18 A (+15d) |  | 0% → 100% | 37d → none | resources none → Peones [400%]; Albañiles; Hormigonera; baseline start none → 2008-11-14; baseline finish none → 2008-11-14 |
| 16 | **Hincado de pilotes** | 2008-11-12 → 2008-11-19 A (+7d) | 2008-12-29 → 2009-01-07 (+9d) |  | 0% → 33% | 0d → 15d | baseline start none → 2008-11-24; baseline finish none → 2009-01-12 |
| 17 | Hincado de pilotes de pilar A | 2008-11-12 → 2008-11-19 A (+7d) | 2008-11-19 → 2008-11-26 A (+7d) |  | 0% → 100% | 0d → none | resources none → Peones [200%]; Grúa; baseline start none → 2008-11-24; baseline finish none → 2008-12-01 |
| 18 | Hincado de pilotes de pilar B | 2008-12-01 → 2008-12-09 (+8d) | 2008-12-09 → 2008-12-16 (+7d) |  |  | 7d → 8d | resources none → Peones [200%]; Grúa; baseline start none → 2008-12-12; baseline finish none → 2008-12-19 |
| 19 | Hincado de pilotes de pilar C | 2008-12-19 → 2008-12-29 (+10d) | 2008-12-29 → 2009-01-07 (+9d) |  |  | 14d → 15d | resources none → Peones [200%]; Grúa; baseline start none → 2009-01-02; baseline finish none → 2009-01-12 |
| 20 | **Diques provisionales** | 2008-10-13 → 2008-11-03 A (+21d) | 2009-02-13 → 2009-02-23 (+10d) | 86d → 77d | 0% → 36% |  | baseline start none → 2008-11-04; baseline finish none → 2009-02-25 |
| 21 | Instalación de diques provisionales pilar A | 2008-10-13 → 2008-11-03 A (+21d) | 2008-10-21 → 2008-11-10 A (+20d) | 7d → 6d | 0% → 100% | 15d → none | resources none → Peones [200%]; Grúa; baseline start none → 2008-11-04; baseline finish none → 2008-11-12 |
| 22 | Instalación de diques provisionales pilar B | 2008-11-20 → 2008-11-27 A (+7d) | 2008-11-28 → 2008-12-05 (+7d) |  | 0% → 29% | 7d → 8d | resources none → Peones [200%]; Grúa; baseline start none → 2008-12-02; baseline finish none → 2008-12-11 |
| 23 | Instalación de diques provisionales pilar C | 2008-12-10 → 2008-12-17 (+7d) | 2008-12-18 → 2008-12-26 (+8d) |  |  | 14d → 15d | resources none → Peones [200%]; Grúa; baseline start none → 2008-12-22; baseline finish none → 2008-12-31 |
| 24 | Recuperación de planchas | 2009-02-12 → 2009-02-20 (+8d) | 2009-02-13 → 2009-02-23 (+10d) |  |  |  | resources none → Peones [200%]; Grúa; baseline start none → 2009-02-24; baseline finish none → 2009-02-25 |
| 25 | **Pasarela** | 2008-10-13 → 2008-11-18 A (+36d) | 2009-02-24 → 2009-03-10 (+14d) | 93d → 77d | 0% → 42% | 12.5d → 4d | baseline start none → 2008-11-17; baseline finish none → 2009-03-10 |
| 26 | Instalación pasarelas | 2008-10-13 → 2008-11-18 A (+36d) | 2008-10-17 → 2008-11-24 A (+38d) |  | 0% → 100% | 50d → none | resources none → Peones [200%]; Albañiles [200%]; Grúa [90%]; baseline start none → 2008-11-17; baseline finish none → 2008-11-21 |
| 27 | Desmontaje pasarelas | 2009-02-16 → 2009-03-02 (+14d) | 2009-02-24 → 2009-03-10 (+14d) |  |  | 12.5d → 4d | resources none → Peones; Albañiles [50%]; Grúa [50%]; baseline start none → 2009-03-02; baseline finish none → 2009-03-10 |
| 28 | **Hormigonado de pilares** | 2008-11-20 → 2008-11-27 A (+7d) | 2009-02-11 → 2009-02-19 (+8d) | 56d → 57d | 0% → 4% |  | baseline start none → 2008-12-02; baseline finish none → 2009-02-23 |
| 29 | Confección traviesas pilar A | 2008-11-20 → 2008-11-27 A (+7d) | 2008-11-26 → 2008-12-04 (+8d) | 5d → 6d | 0% → 33% |  | resources none → Peones [200%]; Albañiles [200%]; Hormigonera; baseline start none → 2008-12-02; baseline finish none → 2008-12-09 |
| 30 | Hormigonado pilar A | 2008-11-27 → 2008-12-05 (+8d) | 2008-12-18 → 2008-12-29 (+11d) |  |  |  | resources none → Peones [200%]; Albañiles [200%]; Hormigonera; baseline start none → 2008-12-10; baseline finish none → 2008-12-31 |
| 31 | Confección traviesas pilar B | 2008-12-19 → 2008-12-30 (+11d) | 2008-12-26 → 2009-01-07 (+12d) |  |  |  | resources none → Peones [200%]; Albañiles [200%]; Hormigonera; baseline start none → 2009-01-02; baseline finish none → 2009-01-09 |
| 32 | Hormigonado pilar B | 2008-12-29 → 2009-01-08 (+10d) | 2009-01-20 → 2009-01-28 (+8d) |  |  |  | resources none → Peones [200%]; Albañiles [200%]; Hormigonera; baseline start none → 2009-01-12; baseline finish none → 2009-01-30 |
| 33 | Confección traviesas pilar C | 2009-01-21 → 2009-01-29 (+8d) | 2009-01-27 → 2009-02-04 (+8d) |  |  |  | resources none → Peones [200%]; Albañiles [200%]; Hormigonera; baseline start none → 2009-02-02; baseline finish none → 2009-02-06 |
| 34 | Hormigonado pilar C | 2009-01-28 → 2009-02-05 (+8d) | 2009-02-11 → 2009-02-19 (+8d) |  |  |  | resources none → Peones [200%]; Albañiles [200%]; Hormigonera; baseline start none → 2009-02-09; baseline finish none → 2009-02-23 |
| 35 | **Tablero** | 2009-02-16 → 2009-02-24 (+8d) | 2009-03-06 → 2009-03-09 (+3d) | 14.5d → 10d |  |  | baseline start none → 2009-02-26; baseline finish none → 2009-03-11 |
| 36 | Colocación vigas prefabricadas | 2009-02-16 → 2009-02-24 (+8d) | 2009-02-17 → 2009-02-25 (+8d) |  |  |  | resources none → Peones [200%]; Albañiles [200%]; Grúa; baseline start none → 2009-02-26; baseline finish none → 2009-02-27 |
| 37 | Encofrado tablero | 2009-02-18 → 2009-02-26 (+8d) | 2009-02-24 → 2009-03-02 (+6d) | 5d → 2.5d |  |  | resources none → Peones [400%]; Albañiles [400%]; Grúa [10%]; baseline start none → 2009-03-02; baseline finish none → 2009-03-04 |
| 38 | Ferralla tablero | 2009-02-25 → 2009-03-03 (+6d) | 2009-03-04 → 2009-03-05 (+1d) | 5d → 2.5d |  |  | resources none → Peones [400%]; Albañiles [400%]; Grúa [10%]; baseline start none → 2009-03-05; baseline finish none → 2009-03-09 |
| 39 | Hormigonado tablero | 2009-03-04 → 2009-03-09 (+5d) | 2009-03-06 → 2009-03-09 (+3d) | 2d → 1d |  |  | resources none → Peones [400%]; Albañiles [400%]; Grúa; baseline start none → 2009-03-11; baseline finish none → 2009-03-11 |
| 40 | **Pretil** | 2008-10-01 A | 2009-03-13 → 2009-03-16 (+3d) | 113.5d → 115d |  |  | baseline start none → 2008-10-01; baseline finish none → 2009-03-18 |
| 41 | Pedido pretil | 2008-10-01 A | 2008-10-01 A |  | 0% → 100% | 88.5d → none | baseline start none → 2008-10-01; baseline finish none → 2008-10-01 |
| 42 | Colocación pretil | 2009-03-06 → 2009-03-10 (+4d) | 2009-03-13 → 2009-03-16 (+3d) |  |  |  | resources none → Peones [200%]; Albañiles; Grúa; baseline start none → 2009-03-12; baseline finish none → 2009-03-18 |
